# Exam Creator Project

Schedule from MS Project, 2003-02-24 to 2003-11-23, costs in $, A marks actual dates.
Home

## Calendars

- Standard: Mon-Sun 08:00-12:00, 13:00-17:00. Exceptions (off unless hours are given): 2003-02-24 to 2003-02-28 08:00-12:00, 13:00-17:00, 2003-03-03 to 2003-03-07 08:00-12:00, 13:00-17:00, 2003-03-10 to 2003-03-14 08:00-12:00, 13:00-17:00, 2003-03-17 08:00-12:00, 13:00-17:00, 2003-06-01 08:00-12:00, 13:00-17:00, 2003-06-02 to 2003-07-26, 2003-07-27 08:00-12:00, 13:00-17:00, 2003-08-02 to 2003-08-03 08:00-12:00, 13:00-17:00, 2003-08-09 to 2003-08-10 08:00-12:00, 13:00-17:00, 2003-08-16 to 2003-08-17 08:00-12:00, 13:00-17:00, 2003-08-23 to 2003-08-24 08:00-12:00, 13:00-17:00, 2003-08-30 to 2003-08-31 08:00-12:00, 13:00-17:00, 2003-09-06 to 2003-09-07 08:00-12:00, 13:00-17:00, 2003-09-13 to 2003-09-14 08:00-12:00, 13:00-17:00, 2003-09-20 to 2003-09-21 08:00-12:00, 13:00-17:00, 2003-09-27 to 2003-09-28 08:00-12:00, 13:00-17:00, 2003-10-04 to 2003-10-05 08:00-12:00, 13:00-17:00, 2003-10-11 to 2003-10-12 08:00-12:00, 13:00-17:00, 2003-10-18 to 2003-10-19 08:00-12:00, 13:00-17:00, 2003-10-25 to 2003-10-26 08:00-12:00, 13:00-17:00.

## Resources

| Resource | Rate | Notes |
| --- | --- | --- |
| Sole Employee (me) | 30 |  |
| MS Word & MS Project |  |  |
| IDE |  | Integrated Development Environment |
| Computer |  |  |

## Schedule

| ID | WBS | Task | Type | Duration | Start | Finish | Predecessors | Complete | Remaining | Total slack | Constraint | Resources | Work | Actual work | Cost | Actual cost |
| --- | --- | --- | --- | --- | --- | --- | --- | --- | --- | --- | --- | --- | --- | --- | --- | --- |
| 1 | 1 | Sem 1 Resources |  | 92d | 2003-02-24 A | 2003-05-26 A |  | 100% |  |  |  | Sole Employee (me); MS Word & MS Project; Computer | 736h | 736h | 22,080 | 22,080 |
| 2 | 2 | Sem 2 Resources |  | 92d? | 2003-07-27 A | 2003-10-26 |  | 47% | 49d? | 28d | start no earlier than 2003-07-27 | Sole Employee (me); MS Word & MS Project; Computer; IDE | 736h | 344h | 22,080 | 10,320 |
| 3 | 3 | **Sem 1 Work (CP3046)** |  | 92d? | 2003-02-24 A | 2003-05-26 A |  | 100% |  |  |  |  |  |  |  |  |
| 4 | 3.1 | **Start Up** |  | 28d? | 2003-02-24 A | 2003-03-24 A |  | 100% |  |  |  |  |  |  |  |  |
| 5 | 3.1.1 | Project Mandate |  | 14d? | 2003-02-24 A | 2003-03-09 A |  | 100% |  |  |  |  |  |  |  |  |
| 6 | 3.1.2 | Project Charter |  | 2d | 2003-03-10 A | 2003-03-11 A | 5 | 100% |  |  |  |  |  |  |  |  |
| 7 | 3.1.3 | Project Stakeholder Analysis |  | 2d | 2003-03-12 A | 2003-03-13 A | 6 | 100% |  |  | start no earlier than 2003-03-05 |  |  |  |  |  |
| 8 | 3.1.4 | Project Scope Statement |  | 5d | 2003-03-14 A | 2003-03-18 A | 7 | 100% |  |  | start no earlier than 2003-03-07 |  |  |  |  |  |
| 9 | 3.1.5 | Project Initlisation Plan (gnatt-chart) |  | 5d | 2003-03-19 A | 2003-03-23 A | 8 | 100% |  |  | start no earlier than 2003-03-08 |  |  |  |  |  |
| 10 | 3.1.6 | (Ass1) Project Proposal Documentation & Presentation | milestone | 0d | 2003-03-24 A | 2003-03-24 A | 9 | 100% |  |  | start no earlier than 2003-03-24 |  |  |  |  |  |
| 11 | 3.2 | **Initialisation** |  | 35d? | 2003-03-24 A | 2003-04-28 A |  | 100% |  |  |  |  |  |  |  |  |
| 12 | 3.2.1 | Project Report |  | 9d? | 2003-03-24 A | 2003-04-01 A | 10 | 100% |  |  | start no earlier than 2003-03-24 |  |  |  |  |  |
| 13 | 3.2.2 | Literature Review |  | 14d? | 2003-04-02 A | 2003-04-15 A | 12 | 100% |  |  | start no earlier than 2003-04-01 |  |  |  |  |  |
| 14 | 3.2.3 | Feasibility Analysis |  | 4d? | 2003-04-16 A | 2003-04-19 A | 13 | 100% |  |  | start no earlier than 2003-04-16 |  |  |  |  |  |
| 15 | 3.2.4 | Project Rist Plan |  | 8d? | 2003-04-20 A | 2003-04-27 A | 14 | 100% |  |  | start no earlier than 2003-04-16 |  |  |  |  |  |
| 16 | 3.2.5 | (Ass2) Project Analysis Documentation & Presentation | milestone | 0d | 2003-04-28 A | 2003-04-28 A | 15 | 100% |  |  | start no earlier than 2003-04-28 |  |  |  |  |  |
| 17 | 3.3 | **Planning (Development Phase)** |  | 29d? | 2003-04-28 A | 2003-05-26 A |  | 100% |  |  |  |  |  |  |  |  |
| 18 | 3.3.1 | High Level Design |  | 13.5d? | 2003-04-28 A | 2003-05-11 A |  | 100% |  |  | start no earlier than 2003-04-28 |  |  |  |  |  |
| 19 | 3.3.2 | Complete WBS |  | 14.5d? | 2003-05-11 A | 2003-05-25 A | 18 | 100% |  |  | start no earlier than 2003-04-28 |  |  |  |  |  |
| 20 | 3.3.3 | (Ass3) Final Planning Documentation & Presentation | milestone | 0d | 2003-05-26 A | 2003-05-26 A | 19 | 100% |  |  | finish no earlier than 2003-05-26 |  |  |  |  |  |
| 21 | 4 | **Sem 2 Work (CP3047)** |  | 119d? | 2003-07-28 A | 2003-11-23 | 3 | 93% | 7.82d? | 0d |  |  |  |  |  |  |
| 22 | 4.1 | **Low-level Design (Development Phase)** |  | 30d? | 2003-07-28 A | 2003-08-27 A |  | 100% |  |  |  |  |  |  |  |  |
| 23 | 4.1.1 | Finalize interface design |  | 7d? | 2003-07-28 A | 2003-08-03 A |  | 100% |  |  | start no earlier than 2003-07-28 |  |  |  |  |  |
| 24 | 4.1.2 | Finalize ER diagrams |  | 9d? | 2003-07-28 A | 2003-08-05 A |  | 100% |  |  | start no earlier than 2003-07-28 |  |  |  |  |  |
| 25 | 4.1.3 | Write psuedo code where necessary |  | 3d? | 2003-08-06 A | 2003-08-08 A | 24 | 100% |  |  | start no earlier than 2003-08-01 |  |  |  |  |  |
| 26 | 4.1.4 | Finished design specifications | milestone | 0d | 2003-08-27 A | 2003-08-27 A | 25 | 100% |  |  | start no earlier than 2003-08-27 |  |  |  |  |  |

Notes:
- 3: ·I'm still not sure how to break down the tasks below - but breaking it into assessment parts seems logical.
- 4: ·Many of the subtasks below arn't necessarily part of a strick waterfall relationship (even though they're shown that way). i.e. many don't need to be done in this specific order, but since I'm the only person working on these, I intend to complete the tasks one at a time.
- 11: ·Many of the subtasks below arn't necessarily part of a strick waterfall relationship (even though they're shown that way).
- 22: ·I'm not sure yet if we're allowed & suppose to finish the interface & UML diagrams during Sem1(CP3046) or Sem2 (CP3047). / ·However, I do strongly suspect that psuedo code is something we're expected to write during Sem2 (& not eariler). / ·Well thought UML diagrams (i.e. class structure) are critical to this project. If my UML is good enough I may even be able to skip the psuedo code phase and be able to write code much earlier - without any significant increase in project risk!

| ID | WBS | Task | Type | Duration | Start | Finish | Predecessors | Complete | Remaining | Total slack | Constraint |
| --- | --- | --- | --- | --- | --- | --- | --- | --- | --- | --- | --- |
| 27 | 4.2 | **Executing (Implementation Phase)** |  | 94d? | 2003-07-28 A | 2003-10-29 |  | 94% | 5.41d? | 25d |  |
| 28 | 4.2.1 | Research best techniques for assessing exams |  | 22d? | 2003-07-28 A | 2003-08-18 |  | 70% | 6.6d? | 97d | start no earlier than 2003-07-28 |
| 29 | 4.2.2 | Write throwaway code |  | 21d? | 2003-07-28 A | 2003-08-17 A |  | 100% |  |  | start no earlier than 2003-07-28 |
| 30 | 4.2.3 | **Create sample output** |  | 91d | 2003-07-31 A | 2003-10-29 A |  | 100% |  |  |  |
| 31 | 4.2.3.1 | Create HTML exam (non-assessable) |  | 12d | 2003-07-31 A | 2003-10-29 A |  | 100% |  |  | start no earlier than 2003-08-04 |
| 32 | 4.2.3.2 | (optional) Create server-side scripting to assess exam |  | 7d | 2003-08-04 A | 2003-08-10 A |  | 100% |  |  |  |
| 33 | 4.2.4 | **Implement minimal version of program** |  | 21d? | 2003-08-11 A | 2003-08-31 |  | 95% | 1d? | 84d |  |
| 34 | 4.2.4.1 | Implement minimal interface |  | 4d? | 2003-08-11 A | 2003-08-14 A | 26 | 100% |  |  | start no earlier than 2003-08-11 |
| 35 | 4.2.4.2 | Establish database to store exam files |  | 5d? | 2003-08-15 A | 2003-08-19 | 34 | 80% | 1d? | 96d | start no earlier than 2003-08-15 |
| 36 | 4.2.4.3 | Implement minimal code |  | 12d? | 2003-08-20 A | 2003-08-31 A | 35 | 100% |  |  | start no earlier than 2003-08-20 |
| 37 | 4.2.4.4 | Minimal version complete | milestone | 0d | 2003-08-31 | 2003-08-31 | 36 |  |  | 84d |  |
| 38 | 4.2.5 | **Implement complete version** |  | 49d? | 2003-09-01 A | 2003-10-20 |  | 99% | 0d? | 35d |  |
| 39 | 4.2.5.1 | Finish interface |  | 5d? | 2003-09-01 A | 2003-09-05 A | 37 | 100% |  |  | start no earlier than 2003-09-01 |
| 40 | 4.2.5.2 | **Finish code** |  | 37d? | 2003-09-06 A | 2003-10-12 A | 39 | 100% |  |  |  |
| 41 | 4.2.5.2.1 | Add all question types |  | 5d? | 2003-09-06 A | 2003-09-10 A |  | 100% |  |  | start no earlier than 2003-09-03 |
| 42 | 4.2.5.2.2 | Allow exams to be saved/loaded |  | 9d? | 2003-09-11 A | 2003-09-19 A |  | 100% |  |  | start no earlier than 2003-09-11 |
| 43 | 4.2.5.2.3 | Allow questions to be moved/deleted |  | 9d? | 2003-09-20 A | 2003-09-28 A |  | 100% |  |  | start no earlier than 2003-09-20 |
| 44 | 4.2.5.2.4 | Allow for various export options |  | 14d? | 2003-09-29 A | 2003-10-12 A |  | 100% |  |  | start no earlier than 2003-09-29 |
| 45 | 4.2.5.3 | Add finishing touches to interface |  | 7d? | 2003-10-13 A | 2003-10-19 A | 40 | 100% |  |  | start no earlier than 2003-10-13 |
| 46 | 4.2.5.4 | Program finished | milestone | 0d | 2003-10-20 | 2003-10-20 | 45 |  |  | 35d | start no earlier than 2003-10-20 |
| 47 | 4.3 | **Controlling** |  | 67d? | 2003-08-20 A | 2003-10-25 |  | 99% | 0.58d? | 29d |  |
| 48 | 4.3.1 | **Testing (bug fixing)** |  | 67d? | 2003-08-20 A | 2003-10-25 | 36SS | 99% | 0.58d? | 29d |  |
| 49 | 4.3.1.1 | Unit Testing |  | 40d? | 2003-08-20 A | 2003-09-28 A |  | 100% |  |  | start no earlier than 2003-08-20 |
| 50 | 4.3.1.2 | System Testing |  | 62d? | 2003-08-25 A | 2003-10-25 A |  | 100% |  |  | start no earlier than 2003-08-25 |
| 51 | 4.3.1.3 | Integration Testing |  | 10d? | 2003-10-13 A | 2003-10-22 A |  | 100% |  |  | start no earlier than 2003-10-13 |
| 52 | 4.3.1.4 | User Testing |  | 3d? | 2003-10-23 A | 2003-10-25 |  | 67% | 1d? | 29d | start no earlier than 2003-10-23 |

Notes:
- 28: ·I still don't know the best type of code (server-side scripting technologies) to use, nor the easiest, most secure methods to assess a "computer exam", then return and store the result. / ·Therefore I will need to look into my options early on, or (better yet) before the project starts.
- 29: I will write small throw-away code wherenever there is: / ·a feature I'm not sure of. (eg: I'm not sure how PHP should mark a test), or/ ·a piece of code I'm unfamiliar with. (eg: I don't know how to read & write to files using Java code) / Even though I'm writing disposable code, this method ensures I have a good idea of how code/concepts integrate before I try and add them into my main program. This reduces project risk.
- 30: ·I will create working example/s of the exams I want Exam Creator to output. / ·Ideally, I shouldn't start coding until this is completely finished, but in reality, I might do a lot of experimenting while I'm writing code.
- 33: The advantage of Exam Creator is its scalability factor. I will implement this program in steps - after the design phase, I will start by making a minimum version of the program. ie: Only the most basic functionality will be included. / ================= / The minimal version: / 1.Initially, I will allow only 1 type of question (True_False_Q) to be entered (but make sure this can be expanded later). / 2.I will make the interface for adding questions, but won't worry about modifying/deleting them for now. / 3.I will forget about export options for now - allow only one simple setting - a simple title, one question after the other, & no section headings, on a single HTML page. / 4.The exported exam will return a result, but be non-assessable exam (ie: it doesn't matter if the student can see/hack into the code which grades the exam).
- 35: ·These classes should be quick to type up (according to my UML). / ·I don't need to write out all methods properly at this stage - just make sure that my hierarchy of classes is established. / ·Even though my goal (at this stage) is to get a minimal working version, its important for me to follow the complete UML structure. If I do this properly (and carefully), it will be very easy to add features to my minimal version, until the program is complete.
- 37: ·Minimal version complete
- 40: ·Because of the careful, scalable method I intend to plan out the classes & code (in the design phase), none of the subtasks below (eg: adding save/load functionality) should have dependencies on each other. / ·i.e. I should be able to add the functionality to save and load an exam after I add the various (remainaing) question types, or vice versa - there are no dependencies amoung these tasks / ·What I have shown below shows a rough estimate of how long each task may take - even though I'll probably do them in a different order, or perhaps do them in parallel.
- 45: Adding the finishing touches to the interface shouldn't be done until ALL other work is complete. / This may include:/ ·adding a "help" screen, / ·adding an "about" screen, / ·making the interface more attractive though use of graphics
- 48: ·Program testing & bug fixing will (obviously) be a continous process. / ·I intend to spend a lot of time searching for any bugs - especially the week before submission.

| ID | WBS | Task | Type | Duration | Start | Finish | Predecessors | Complete | Remaining | Total slack | Constraint |
| --- | --- | --- | --- | --- | --- | --- | --- | --- | --- | --- | --- |
| 53 | 4.4 | **Closing** |  | 35d? | 2003-10-20 A | 2003-11-23 |  | 41% | 20.59d? | 0d |  |
| 54 | 4.4.1 | User Documentation |  | 6d? | 2003-10-20 A | 2003-10-25 A | 46 | 100% |  |  |  |
| 55 | 4.4.2 | Publish final CD & user documentation |  | 1d? | 2003-10-26 A | 2003-10-26 A | 48, 54 | 100% |  |  | start no earlier than 2003-10-26 |
| 56 | 4.4.3 | Project Due | milestone | 0d | 2003-11-19 | 2003-11-19 | 55 |  |  | 0d | start no earlier than 2003-11-19 |
| 57 | 4.4.4 | **Training** |  | 5d? | 2003-11-19 | 2003-11-23 | 56 |  |  | 0d |  |
| 58 | 4.4.4.1 | Training network administrators (IT&R) |  | 5d? | 2003-11-19 | 2003-11-23 |  |  |  | 0d |  |
| 59 | 4.4.4.2 | Training lecturers |  | 5d? | 2003-11-19 | 2003-11-23 | 58 |  |  | 0d | start no earlier than 2003-10-28 |

Notes:
- 54: ·Are we required to produce user documentation? / ·Are we required to produce any other type of documentation?
- 55: Add notes here
- 56: ·I still don't know what formal submission I have to make.
- 57: Add notes here
